# Plan frem til delfrist 1

Schedule from MS Project, 2008-10-06 to 2010-05-27, 10 hours a day.

## Calendars

- Vinjefjorden: Mon-Fri 08:00-12:00, 13:00-17:00; Sat-Sun off. Exceptions (off unless hours are given): 2008-10-20 to 2010-06-01 07:00-11:00, 12:00-17:00 (Arbeidstider, recurring), 2008-10-24 to 2010-06-04 (Fridag, recurring), 2008-12-22 to 2009-01-02 (Jul), 2009-04-06 to 2009-04-13 (Påske).

## Resources

| Resource |
| --- |
| Gravemaskin 30tonn m. ekstra stikke |
| Dumper Volvo A25 |
| Spregningsbas |
| Sprengningsarbeider |
| Gravemaskin med boreutstyr nr.1 |
| Hjullaster 1 |
| Hjullaster 2 |
| Hjullaster 3 |
| Gravemaskin med boreutstyr nr.2 |
| Gravemaskin 40tonn |
| Dumper 1 |
| Dumper 2 |
| Asfaltfres |
| Lastebil 1 |
| Lastebil 2 |
| Gravemaskin 30 tonn nr.2 |
| Fjellikringsarbeider 1 |
| Fjellsikringsarbeider 2 |
| Korglift |

## Schedule

| ID | WBS | Task | Duration | Start | Finish | Predecessors | Total slack | Free slack | Constraint | Deadline | Resources | Work |
| --- | --- | --- | --- | --- | --- | --- | --- | --- | --- | --- | --- | --- |
| 1 | 1 | **Busteinsbukta - Svadalsryggen** | 298d | 2008-10-06 | 2010-05-27 |  | 0d |  | finish no later than 2010-06-01 | 2010-06-01 |  | 2951.47h |
| 3 | 1.1 | **Generelt** | 298d | 2008-10-06 | 2010-05-27 |  | 0d |  |  |  |  |  |
| 4 | 1.1.1 | Sette opp riggen og ordne til området | 4d | 2008-10-06 | 2008-10-10 |  | 0d |  | finish no later than 2008-10-10 |  |  |  |
| 5 | 1.1.2 | Utsetting, stikning oppmåling og dokumentasjon | 294d | 2008-10-13 | 2010-05-27 | 4 | 2.5d | 0d | start no earlier than 2008-10-13 |  |  |  |
| 7 | 1.2 | **Delfrist 1. 1 mars 2009** | 63.2d | 2008-10-15 | 2009-02-27 |  | 0d |  | finish no later than 2009-03-01 | 2009-03-01 |  | 2951.47h |
| 9 | 1.2.1 | Fjerning av skog og kratt, start v. profil 5690 | 12d | 2008-10-15 | 2008-11-06 | 5SS+2d | 12.7d |  |  |  |  |  |
| 10 | 1.2.2 | **Mellom profilene 5070 - 5210** | 24.6d | 2008-12-09 | 2009-02-09 |  | 5.6d |  |  |  |  | 780.48h |
| 11 | 1.2.2.1 | Avtaking av vegetasjon og matjord | 5d | 2008-12-09 | 2008-12-17 | 20 | 1.4d | 0d | start no earlier than 2008-11-10 |  | Gravemaskin 30tonn m. ekstra stikke | 50h |
| 12 | 1.2.2.2 | Boring, ladning og sprengning for pilotveg | 2d | 2008-12-09 | 2009-01-05 | 11SS | 5.6d | 0d | start no earlier than 2008-11-03 |  | Spregningsbas [50%]; Sprengningsarbeider [50%]; Gravemaskin med boreutstyr nr.2 | 40h |
| 13 | 1.2.2.3 | Opplasting og kjøring jord til lager pr. 6700 | 4d | 2009-01-05 | 2009-01-12 | 12 | 24.3d |  |  |  | Dumper 1 | 40h |
| 14 | 1.2.2.4 | Boring for salver på 5000 m3 per stk | 9d | 2009-01-05 | 2009-01-29 | 12 | 10.2d | 0d |  |  | Gravemaskin med boreutstyr nr.2 | 90h |
| 15 | 1.2.2.5 | Ladning og sprengning | 5d | 2009-01-06 | 2009-01-29 | 14SS+1d | 10.2d | 0d | start no earlier than 2008-11-12 |  | Spregningsbas; Sprengningsarbeider | 100h |
| 16 | 1.2.2.6 | Sikring og rensk av fjell | 7d | 2008-12-11 | 2009-02-03 | 12SS+2d | 5.6d |  |  |  | Fjellikringsarbeider 1; Fjellsikringsarbeider 2; Korglift; Gravemaskin 30tonn m. ekstra stikke | 226h |
| 17 | 1.2.2.7 | Sprengt stein til sjøtipp pr. 5450 | 9d | 2009-01-08 | 2009-02-03 | 15SS+2d | 10.2d | 0d | start no earlier than 2008-11-18 |  | Hjullaster 3; Gravemaskin 40tonn; Dumper 1; Dumper 2 | 234.47h |
| 18 | 1.2.2.8 | Bygge ny plasstøpt mur pr. 5190-5225 | 8d | 2009-01-22 | 2009-02-09 | 17FS-5d | 10.2d |  | finish no later than 2009-02-27 | 2009-05-19 |  |  |
| 19 | 1.2.3 | **Mellom profilene 5210 - 5690** | 50.3d | 2008-11-10 | 2009-02-27 |  | -0.2d | 0d |  |  |  | 2171h |
| 20 | 1.2.3.1 | Avtaking av vegetasjon og matjord | 17d | 2008-11-10 | 2008-12-09 | 9SS | -1d | 0d | start no earlier than 2008-11-10 |  | Gravemaskin 30tonn m. ekstra stikke | 170h |
| 21 | 1.2.3.2 | Boring, ladning og sprengning for pilotveg | 8d | 2008-11-10 | 2008-12-01 | 20SS | -0.2d | 0d | start no earlier than 2008-11-03 |  | Gravemaskin med boreutstyr nr.1 [50%]; Spregningsbas [50%]; Sprengningsarbeider [50%]; Gravemaskin med boreutstyr nr.2 | 116h |
| 22 | 1.2.3.3 | Boring for salver på 5000 m3 per stk | 27d | 2008-11-13 | 2009-01-20 | 21SS+3d | -0.2d | 0d |  |  | Gravemaskin med boreutstyr nr.1 | 270h |
| 23 | 1.2.3.4 | Ladning og sprengning | 18d | 2008-11-17 | 2009-02-05 | 22SS+1d | -0.2d | 0d | start no earlier than 2008-11-12 |  | Spregningsbas; Sprengningsarbeider | 360h |
| 24 | 1.2.3.5 | Sikring og rensk av fjell | 12d | 2008-11-12 | 2009-02-12 | 21SS+2d | 7.5d | 0d |  |  | Fjellikringsarbeider 1; Fjellsikringsarbeider 2; Korglift; Gravemaskin 30 tonn nr.2 | 480h |
| 25 | 1.2.3.6 | Sprengt stein til fylling, knusing og sjøtipp pr.5450 | 31d | 2008-11-19 | 2009-02-11 | 23SS+2d | -0.2d | 0d | start no earlier than 2008-11-18 |  | Hjullaster 1; Hjullaster 2; Hjullaster 3 | 775h |
| 26 | 1.2.3.7 | Bygge ny plasstøpt mur pr. 5415-5445 | 8d | 2009-01-08 | 2009-01-26 | 25FS-17d | -0.2d | 0d | finish no later than 2009-02-27 |  |  |  |
| 27 | 1.2.3.8 | Bygge ny plasstøpt mur pr. 5550-5650 | 18d | 2009-01-26 | 2009-02-27 | 26 | -0.2d | 0d | finish no later than 2009-02-27 |  |  |  |

| ID | WBS | Task | Duration | Start | Finish | Predecessors | Total slack | Free slack | Constraint |
| --- | --- | --- | --- | --- | --- | --- | --- | --- | --- |
| 29 | 1.3 | **Sprengning og masseflytting** | 164d | 2008-10-21 | 2009-09-28 |  | 127.6d |  |  |
| 30 | 1.3.1 | **Riving og fjerning** | 24.7d | 2008-10-21 | 2008-12-08 |  | 266.9d |  |  |
| 31 | 1.3.1.1 | Riving naust profil 5920 | 1d | 2008-12-01 | 2008-12-02 |  | 267.9d | 0d | start no earlier than 2008-12-01 |
| 32 | 1.3.1.2 | Riving naust profil 6885 | 1d | 2008-12-02 | 2008-12-03 | 31 | 267.9d | 0d |  |
| 33 | 1.3.1.3 | Riving naust profil 6900 | 1d | 2008-12-03 | 2008-12-04 | 32 | 267.9d |  |  |
| 34 | 1.3.1.4 | Riving og fjerning plasstøpte støttemurer i 6880 og 7100 | 4d | 2008-12-01 | 2008-12-08 |  | 266.9d |  | start no earlier than 2008-12-01 |
| 35 | 1.3.1.5 | Flytting og omlegging av 3 private vann- og avløpsledninger | 4d | 2008-12-01 | 2008-12-08 |  | 266.9d |  | start no earlier than 2008-12-01 |
| 36 | 1.3.1.6 | Fjerning av eksisterende asfalt | 12d | 2008-10-21 | 2008-11-12 |  | 279.6d |  | start no earlier than 2008-10-21 |
| 37 | 1.3.2 | Avtaking av vegetasjonsdekke og matjord | 38d | 2009-02-09 | 2009-07-27 | 38SS-1d | 136.5d | 0d |  |
| 38 | 1.3.3 | **Sprengning** | 84d | 2009-02-10 | 2009-07-30 |  | 133.6d | 0d |  |
| 39 | 1.3.3.1 | Sprengning mellom pr. 5690 - 5890 (7500 fm3) | 6d | 2009-02-10 | 2009-02-23 | 23FS+2d | 133.6d | 0d |  |
| 40 | 1.3.3.2 | Sprengning mellom pr. 6010-6230 (17 800 fm3) | 12d | 2009-02-23 | 2009-03-17 | 39 | 133.6d | 0d |  |
| 41 | 1.3.3.3 | Sprengning mellom pr. 6910-7660 (99 200 fm3) | 66d | 2009-03-17 | 2009-07-30 | 40 | 133.6d | 0d |  |
| 42 | 1.3.4 | Maskin-, spyl og spettrensk | 25d | 2009-02-12 | 2009-08-11 | 38SS+2d | 151.7d | 0d | finish no earlier than 2009-08-11 |
| 43 | 1.3.5 | Fjellsikring. Bolting, nett og båndarbeid | 40d | 2009-03-04 | 2009-09-28 | 42SS+10d | 127.6d |  |  |
| 44 | 1.3.6 | Masseflytting av jord | 14d | 2009-02-16 | 2009-09-09 | 37SS+4d | 136.5d |  |  |
| 45 | 1.3.7 | **Masseflytting av sprengt stein** | 75.6d | 2009-02-26 | 2009-08-03 |  | 156.2d |  |  |
| 46 | 1.3.7.1 | Sprengt stein til fylling pr.5620 - 6750 (5900fm3) | 6d | 2009-02-26 | 2009-03-11 | 39FS+3d | 225.8d |  |  |
| 47 | 1.3.7.2 | Sprengt stein til fylling pr.5840 - 6030 (10900fm3) | 11d | 2009-02-26 | 2009-03-19 | 40SS+3d | 220.8d |  |  |
| 48 | 1.3.7.3 | Sprengt stein til fylling pr.6220 - 6440 (5000fm3) | 5d | 2009-03-09 | 2009-03-17 | 40SS+3d | 222.7d |  | start no earlier than 2009-03-09 |
| 49 | 1.3.7.4 | Sprengt stein til fylling pr.6700 - 6920 (3800fm3) | 4d | 2009-03-23 | 2009-03-31 | 41SS+3d | 215.8d |  |  |
| 50 | 1.3.7.5 | Sprengt stein til sjøtipp pr. 5450 | 8d | 2009-03-17 | 2009-04-01 | 40SS+12d | 214.8d |  |  |
| 51 | 1.3.7.6 | Sprengt stein til sjøtipp pr. 7660(+) og knusing | 30d | 2009-03-30 | 2009-08-03 | 41SS+6d | 156.2d |  |  |
| 54 | 1.4 | **Grøfter, kummer og rør** | 222.2d | 2008-11-12 | 2010-02-10 |  | 57.4d |  |  |
| 55 | 1.4.1 | Flytting av lavspent- og telekabler i Engdalen 200m | 3d | 2009-04-20 | 2009-04-23 |  | 187.6d | 0d | start no earlier than 2009-04-20 |
| 56 | 1.4.2 | Åpen grøft i Engdalen mellom pr. 6620 - 6820 | 14d | 2009-04-23 | 2009-05-20 | 55 | 187.6d | 0d |  |

Notes:
- 34: Riving og fjerning av eksisterende plasstøpte støttemurer / ved profil 6880 og 7100. Tilsammen ca. 200 m2.
- 35: 16.2 Flytting og omlegging av private vann- og avløpsledninger, / brønner / a) Gjelder flytting/reparasjon av 3 private avløpssystem i / Engdalen (ca. 100 m. ledning Ø110 mm plast) inkl. 1 stk. / septikktank RS
- 36: 15.42 Riving og fjerning av faste vegdekker / a) Eksisterende asfalt på dagens parsell består av ca 4 cm / frest/anriket masse (ottadekke/oljegrus) nederst. Over det / ligger ca 4 cm Agb16 (lagt i 1997). / Asfaltmasse som må graves bort tillates ikke brukt i ny / vegfylling. / Asfaltmasse som ikke freses og/eller knuses og brukes i ny / overbygning må leveres godkjent mottak. Nærmeste mottak / er i Hagelin i Kristiansund (Kristiansund kommune) og på / Grønøra i Orkdal (Mardahl Pukk AS). / m2 13 000
- 37: a) Prosessen omfatter riving og fjerning av stubber og røtter / samtidig med fjerning av vegetasjonsdekke. / Masse fjernes til 2,0 m utenfor prosjektert skjæringstopp. / Prosessen gjelder også matjordavtak på ca. 400 m ny / adkomstveg i Engdalen / c) Kjøres til anviste deponiplasser. Transportavstand inntil 6 / km (12 km tur/retur) for deponering. / Massen skal senere brukes til kledning av / fyllingsskråninger. / . m3 5 000
- 42: 23.12 Maskinrensk / a) Omfatter fjerning av løst berg ved bruk av maskin med pigghammer / Det tilstrebes en rensk tilsvarende spettrensk. Hvis maskinrensken skal / utføres med full effekt, må det klarlegges at dette kan skje uten økt / rasfare og behov for sikring. / c) / x) Avregnes etter medgått tid for maskinfører og utstyr. Enhet: time time 200
- 55: 44.111 Grøfter i jord / *** Spesiell beskrivelse *** / a) Gjelder flytting av lavspent- og telekabler i Engdalen m 200
- 56: 41.1 Åpne grøfter i løsmasse / x) Mengden måles som prosjektert lengde. Enhet: m / *** Spesiell beskrivelse *** / a) Gjelder bekk/åpen grøft pr. 6620 - 6820 i Engdalen m 200

| ID | WBS | Task | Duration | Start | Finish | Predecessors | Total slack | Free slack | Constraint |
| --- | --- | --- | --- | --- | --- | --- | --- | --- | --- |
| 57 | 1.4.3 | **Rørlegging** | 213.2d | 2008-12-01 | 2010-02-10 |  | 57.4d |  |  |
| 58 | 1.4.3.1 | Drens | 80d | 2008-12-01 | 2010-02-10 | 68SS | 57.4d |  |  |
| 59 | 1.4.3.2 | Overvann | 70d | 2008-12-01 | 2010-01-14 | 68SS | 71d |  |  |
| 60 | 1.4.3.3 | Spillvann (100m privat) | 6d | 2009-05-20 | 2009-06-02 | 56 | 187.6d |  |  |
| 61 | 1.4.4 | Stikkrenner | 30d | 2008-12-01 | 2009-07-14 | 68SS | 165.9d |  |  |
| 62 | 1.4.5 | Bygging av kulvert "Ytterbønbekken" | 14d | 2009-03-02 | 2009-03-26 |  | 217.3d |  | start no earlier than 2009-03-02 |
| 63 | 1.4.6 | Steinplastring | 10d | 2008-11-12 | 2009-08-04 | 24SS | 155.3d |  |  |
| 66 | 1.5 | **Vegfundament** | 251.5d | 2008-12-01 | 2010-04-26 |  | 12.1d | 0d |  |
| 68 | 1.5.1 | Avretting, justering og komprimering av planum på sprengt stein | 30d | 2008-12-01 | 2009-10-06 | 25SS+5d | 12.1d | 0d |  |
| 69 | 1.5.2 | Forsterkningslag av knuste steinmaterialer (20-100mm) | 17d | 2008-12-03 | 2010-02-23 | 68SS+2d | 12.1d | 0d |  |
| 70 | 1.5.3 | Forsterkningslag av sprengt stein | 18d | 2009-04-23 | 2010-02-11 |  | 49.4d |  |  |
| 71 | 1.5.4 | Bærelag av knuste steinmaterialer (0-32mm) | 12d | 2008-12-16 | 2010-03-17 | 69SS+6d | 12.1d | 0d |  |
| 72 | 1.5.5 | Bærelag av asfaltert grus (AG) | 20d | 2010-03-17 | 2010-04-26 | 71 | 12.1d |  |  |
| 75 | 1.6 | **Vegutstyr og miljøtiltak** | 265.5d | 2008-11-17 | 2010-05-10 |  | 12.1d |  |  |
| 76 | 1.6.1 | Mur av naturstein i Engdalen, pr. 6910-6940 | 5d | 2009-06-01 | 2009-06-09 |  | 184d |  | start no earlier than 2009-06-01 |
| 77 | 1.6.2 | Sognemur | 10d | 2008-11-17 | 2009-10-06 | 24SS+2d | 122.7d |  |  |
| 78 | 1.6.3 | Sluttarbeid, skilt, rekkverk o.l | 7d | 2010-04-26 | 2010-05-10 | 66 | 12.1d |  |  |

Notes:
- 58: 2680 m
- 62: 45.5 Kulvert av spesial-element / a) Bygging av ny Ytterbønbekken kulvert pr. 6350 av / prefabrikerte betongelementer. B=4,0 m., H=3,0 m. / Kfr. tegning K101 / c) Midlertidig flytting/omlegging av eksisterende veg / inngår i prosessen. / Kulverten skal innvendig tilrettelegges for oppgang av fisk / ved at tilstedeværende grusmasser legges tilbake i bunn av / kulvert med midlere tykkelse ca. 40 cm. / I tillegg skal det innvendig på en side anlegges en gangsti av / sprengt stein bredde ca. 1,5 m., høyde ca. 0,8 m. / Viser til skisse på tegning K101.
- 63: 47.71 Steinplastring / m2 200
- 69: 53.2 Forsterkningslag av knuste steinmaterialer / b) 20-100 mm kult / Henholdsvis 20 cm og 30 cm / m3 6 500
- 70: 53.3 Forsterkningslag av sprengt stein / b) Til forsterkningslagsmasse brukes sprengtstein fra linja. / Hovedveg: / 65 cm sprengstein Dmaks<40 cm. evt. sortert sprengstein / 20-250 mm / Sideveg Engdalen: / 50 cm sprengstein Dmaks=250 mm / m3 11 500
- 71: 54.2 Bærelag av knuste steinmaterialer (Fk) / a) Det er overskudd på sprengtstein på anlegget og / entreprenøren kan vederlagsfritt ta denne til produksjon av / bærelagsmasse forutsatt at kvalitet på fjellet tilfredsstiller / krav i Vegnormalene, Håndbok 018 kap. 5. / b) Bærelag på hovedveg: 10 cm Fk 0-32 mm / Bærelag på sideveg med grusdekke: 15 cm Fk 0-32 mm / x) Dersom entreprenøren bruker sprengtstein fra anlegget som / råstoff til produksjon av bærelagsmasser eller andre / fraksjoner trekkes medgåtte mengder fra prosess 26.5. / Det regnes at det går med 0,5 pfm3 fjell for å produsere / 1 pam3 knust masse. m3 3 000
- 72: 55 BÆRELAG AV BITUMENSTABILISERTE / MATERIALER / 55.1 Bærelag av asfaltert grus (Ag) / b) 6 cm Ag 16 øvre bærelag tonn 3 300
- 76: 71.1 Murer av naturstein / a) Gjelder mur pr. 6910-6940 i Engdalen. / Innbefatter også frontmur for kulverter og stikkrenner. / c) For utførelse henvises til tegning J001 og håndbok HB 182 / Tørrmuring med maskin (Rettledning) / m2 250
